# Pipe Repairs & Improvement

How a schedule from Primavera P6 changed from version to version. A marks actual dates.

## Version 1 (data date 2031-06-02, saved 2026-01-29, file PIPE REPAIRS-EV-BL.xer)

| ID | WBS | Task | Duration | Start | Finish | Predecessors | Total float |
| --- | --- | --- | --- | --- | --- | --- | --- |
| A1000 |  | Contract Award Date | 0d | 2031-06-02 | 2031-06-02 |  | 0d |
| A1010 |  | Start Project | 0d | 2031-06-04 | 2031-06-04 | A1000 SS+6d | 0d |
| A1020 |  | Project Management | 18d | 2031-06-04 | 2031-06-27 | A1010 SS | 0d |
| A1030 |  | Project Completion Date | 0d | 2031-06-27 | 2031-06-27 | A1140 FF, A1020 FF | 0d |
|  | 1 | **Demolition Piping** |  | 2031-06-04 | 2031-06-05 |  |  |
| A1040 |  | Drain Piping System | 1d | 2031-06-04 | 2031-06-04 | A1010 SS | 0d |
| A1050 |  | Remove Damaged Piping | 1d | 2031-06-05 | 2031-06-05 | A1040 | 0d |
|  | 2 | **Installation Piping System** |  | 2031-06-06 | 2031-06-27 |  |  |
|  | 1 | **Piping** |  | 2031-06-06 | 2031-06-20 |  |  |
| A1060 |  | Install Piping & Couplings | 3d | 2031-06-06 | 2031-06-10 | A1050 | 0d |
| A1070 |  | Test Piping at Pressure | 1d | 2031-06-11 | 2031-06-11 | A1060 | 0d |
| A1080 |  | Insulate Piping | 4d | 2031-06-17 | 2031-06-20 | A1070, A1120 FF | 0d |
|  | 2 | **Thrustblock** |  | 2031-06-12 | 2031-06-20 |  |  |
| A1090 |  | Set Forms | 1d | 2031-06-12 | 2031-06-12 | A1070 | 0d |
| A1100 |  | Lay Rebar | 1d | 2031-06-13 | 2031-06-13 | A1090 | 0d |
| A1110 |  | Pour Concrete | 1d | 2031-06-16 | 2031-06-16 | A1100 | 0d |
| A1120 |  | Strike Forms | 1d | 2031-06-20 | 2031-06-20 | A1110 FS+9d | 0d |
|  | 3 | **Quality Assuarance** |  | 2031-06-23 | 2031-06-27 |  |  |
| A1130 |  | Write Quality Assurance Report | 4d | 2031-06-23 | 2031-06-26 | A1080 | 0d |
| A1140 |  | Final Quality Assurance Inspection | 1d | 2031-06-27 | 2031-06-27 | A1130 | 0d |

## Version 2 (data date 2031-06-16, saved 2026-01-29, file PIPE REPAIRS-EV.xer)

Last finish 2031-06-27 → 2031-07-07 (+10d). Complete tasks 0 → 4.

Changed:

| ID | Task | Start | Finish | Complete | Total float |
| --- | --- | --- | --- | --- | --- |
| A1000 | Contract Award Date | 2031-06-02 A | 2031-06-02 A | 0% → 100% | 0d → none |
| A1010 | Start Project | 2031-06-04 A | 2031-06-04 A | 0% → 100% | 0d → none |
| A1020 | Project Management | 2031-06-04 A | 2031-06-27 → 2031-07-07 (+10d) | 0% → 19% |  |
| A1030 | Project Completion Date | 2031-06-27 → 2031-07-07 (+10d) | 2031-06-27 → 2031-07-07 (+10d) |  |  |
| 1 | **Demolition Piping** | 2031-06-04 → 2031-06-05 (+1d) | 2031-06-05 → 2031-06-06 (+1d) |  |  |
| A1040 | Drain Piping System | 2031-06-04 → 2031-06-05 A (+1d) | 2031-06-04 → 2031-06-05 A (+1d) | 0% → 100% | 0d → none |
| A1050 | Remove Damaged Piping | 2031-06-05 → 2031-06-06 A (+1d) | 2031-06-05 → 2031-06-06 A (+1d) | 0% → 100% | 0d → none |
| 2 | **Installation Piping System** | 2031-06-06 → 2031-06-09 (+3d) | 2031-06-27 → 2031-07-07 (+10d) |  |  |
| 1 | **Piping** | 2031-06-06 → 2031-06-09 (+3d) | 2031-06-20 → 2031-06-27 (+7d) |  |  |
| A1060 | Install Piping & Couplings | 2031-06-06 → 2031-06-09 A (+3d) | 2031-06-10 → 2031-06-17 (+7d) | 0% → 50% |  |
| A1070 | Test Piping at Pressure | 2031-06-11 → 2031-06-17 (+6d) | 2031-06-11 → 2031-06-18 (+7d) |  |  |
| A1080 | Insulate Piping | 2031-06-17 → 2031-06-23 (+6d) | 2031-06-20 → 2031-06-27 (+7d) |  |  |
| 2 | **Thrustblock** | 2031-06-12 → 2031-06-18 (+6d) | 2031-06-20 → 2031-06-27 (+7d) |  |  |
| A1090 | Set Forms | 2031-06-12 → 2031-06-18 (+6d) | 2031-06-12 → 2031-06-19 (+7d) |  |  |
| A1100 | Lay Rebar | 2031-06-13 → 2031-06-19 (+6d) | 2031-06-13 → 2031-06-20 (+7d) |  |  |
| A1110 | Pour Concrete | 2031-06-16 → 2031-06-20 (+4d) | 2031-06-16 → 2031-06-23 (+7d) |  |  |
| A1120 | Strike Forms | 2031-06-20 → 2031-06-26 (+6d) | 2031-06-20 → 2031-06-27 (+7d) |  |  |
| 3 | **Quality Assuarance** | 2031-06-23 → 2031-06-27 (+4d) | 2031-06-27 → 2031-07-07 (+10d) |  |  |
| A1130 | Write Quality Assurance Report | 2031-06-23 → 2031-06-27 (+4d) | 2031-06-26 → 2031-07-03 (+7d) |  |  |
| A1140 | Final Quality Assurance Inspection | 2031-06-27 → 2031-07-03 (+6d) | 2031-06-27 → 2031-07-07 (+10d) |  |  |
